# MS公開テンプレート

Schedule from MS Project, 2009-06-09 to 2010-01-21.
CB驛ｨ

## Calendars

- 標準: Mon-Fri 08:00-12:00, 13:00-17:00; Sat-Sun off.

## Resources

| Resource |
| --- |
| 上級ＳＥ |
| 開発者 |
| テスト実施者 |
| ユーザー |
| 管理者 |
| アナリスト |
| 中級ＳＥ |
| 基盤技術 |

## Schedule

| ID | WBS | Task | Type | Duration | Start | Finish | Predecessors | Total slack | Free slack | Constraint | Deadline | Resources | Work | 主要なアウトプット |
| --- | --- | --- | --- | --- | --- | --- | --- | --- | --- | --- | --- | --- | --- | --- |
| 1 | 1 | **主要マイルストーン** |  | 160d | 2009-06-12 | 2010-01-21 |  | -162d | 0d |  |  |  |  |  |
| 2 | 1.1 | 設計・開発完了 | milestone | 1d | 2010-01-21 | 2010-01-21 | 29 | -162d | 0d | start no earlier than 2009-06-09 | 2009-06-09 |  |  |  |
| 3 | 1.2 | テスト全体計画 社内レビュー | milestone | 1d | 2009-06-12 | 2009-06-12 | 32 | -3d | 0d | start no earlier than 2009-06-09 | 2009-06-09 |  |  |  |
| 4 | 1.3 | 運用（受入）テスト | milestone | 1d | 2009-09-03 | 2009-09-03 | 41 | -62d | 0d | start no earlier than 2009-06-09 | 2009-06-09 |  |  |  |
| 5 | 1.4 | マニュアル 顧客レビュー | milestone | 1d | 2009-09-08 | 2009-09-08 | 45 | -65d | 0d | start no earlier than 2009-06-09 | 2009-06-09 |  |  |  |
| 6 | 1.5 | ユーザー検収作業 | milestone | 1d | 2009-11-17 | 2009-11-17 | 62 | -115d | 0d | start no earlier than 2009-06-09 | 2009-06-09 |  |  |  |
| 7 | 1.6 | プロジェクト完了評価 | milestone | 1d | 2009-11-19 | 2009-11-19 | 68 | -117d | 0d | start no earlier than 2009-06-09 | 2009-06-09 |  |  |  |
| 9 | 2 | **設計・開発作業** |  | 150d | 2009-06-11 | 2010-01-06 |  | -162d | 0d |  |  |  | 1640h |  |
| 10 | 2.1 | **統合アプリケーション** |  | 125d | 2009-06-11 | 2009-12-02 |  | -137d | 0d |  |  |  | 1120h |  |
| 11 | 2.1.1 | **システム基盤共通機能** |  | 110d | 2009-06-11 | 2009-11-11 |  | -136d | 0d |  |  |  | 704h |  |
| 12 | 2.1.1.1 | 設計 |  | 28d | 2009-06-11 | 2009-07-20 |  | -136d | 0d |  |  | 上級ＳＥ | 224h |  |
| 13 | 2.1.1.2 | 開発 |  | 35d | 2009-07-21 | 2009-09-21 | 12 | -122d | 0d |  |  | 開発者 | 280h | ソースコード |
| 14 | 2.1.1.3 | 単体テスト |  | 25d | 2009-09-22 | 2009-11-11 | 13 | -122d | 0d |  |  | テスト実施者 | 200h | 単体ﾃｽﾄ結果報告書 |
| 15 | 2.1.2 | **現行システムデータ連携** |  | 89d | 2009-07-31 | 2009-12-02 |  | -137d | 0d |  |  |  | 416h |  |
| 16 | 2.1.2.1 | 設計 |  | 22d | 2009-07-31 | 2009-08-31 | 12 | -136d | 0d |  |  | 上級ＳＥ | 176h |  |
| 17 | 2.1.2.2 | 開発 |  | 15d | 2009-10-13 | 2009-11-02 | 16 | -136d | 0d |  |  | 開発者 | 120h | ソースコード |
| 18 | 2.1.2.3 | 単体テスト |  | 15d | 2009-11-12 | 2009-12-02 | 17 | -137d | 0d |  |  | テスト実施者 | 120h | 単体ﾃｽﾄ結果報告書 |
| 19 | 2.2 | **画面設計・開発** |  | 80d | 2009-09-08 | 2009-12-28 | 12 | -155d | 0d |  |  |  | 240h | ｼｽﾃﾑ機能仕様書 |
| 20 | 2.2.1 | **コード入力系画面部分** |  | 80d | 2009-09-08 | 2009-12-28 |  | -155d | 0d |  |  |  | 240h |  |
| 21 | 2.2.1.1 | 画面設計 |  | 5d | 2009-09-08 | 2009-09-14 |  | -155d | 0d |  |  | 上級ＳＥ | 40h | 画面設計書 |
| 22 | 2.2.1.2 | 開発 |  | 15d | 2009-11-24 | 2009-12-14 | 21 | -155d | 0d |  |  | 開発者 | 120h | ソースコード |
| 23 | 2.2.1.3 | 単体テスト |  | 10d | 2009-12-15 | 2009-12-28 | 22 | -155d | 0d |  |  | テスト実施者 | 80h | 単体ﾃｽﾄ結果報告書 |
| 24 | 2.3 | **帳票設計・開発** |  | 92d | 2009-09-01 | 2010-01-06 | 12 | -162d | 0d |  |  |  | 280h | ｼｽﾃﾑ機能仕様書 |
| 25 | 2.3.1 | **管理帳票レポート部分** |  | 92d | 2009-09-01 | 2010-01-06 |  | -162d | 0d |  |  |  | 280h |  |
| 26 | 2.3.1.1 | 帳票設計 |  | 5d | 2009-09-01 | 2009-09-07 |  | -161d | 0d |  |  | 上級ＳＥ | 40h | 帳票設計書 |
| 27 | 2.3.1.2 | 開発 |  | 15d | 2009-11-03 | 2009-11-23 | 26 | -161d | 0d |  |  | 開発者 | 120h | ソースコード |
| 28 | 2.3.1.3 | 単体テスト |  | 15d | 2009-12-03 | 2010-01-06 | 27 | -162d | 0d |  |  | テスト実施者 | 120h | 単体ﾃｽﾄ結果報告書 |
| 29 | 3 | 設計・開発完了レビュー |  | 10d | 2010-01-07 | 2010-01-20 | 14, 18, 23, 28 | -162d | 0d |  |  | ユーザー | 80h |  |

| ID | WBS | Task | Type | Duration | Start | Finish | Predecessors | Total slack | Free slack | Resources | Work | 主要なアウトプット |
| --- | --- | --- | --- | --- | --- | --- | --- | --- | --- | --- | --- | --- |
| 30 | 4 | **テスト＆検証作業** |  | 62d | 2009-06-09 | 2009-09-02 |  | -110d | 0d |  | 496h |  |
| 31 | 4.1 | テスト全体計画作成 |  | 2d | 2009-06-09 | 2009-06-10 |  | -110d | 0d | 上級ＳＥ | 16h | 結合テスト計画書 |
| 32 | 4.2 | テスト全体計画 社内レビュー |  | 1d | 2009-06-11 | 2009-06-11 | 31 | -110d | 0d | 管理者 | 8h | 工程計画のレビュー記録 |
| 33 | 4.3 | **結合テスト** |  | 21d | 2009-06-12 | 2009-07-10 | 32 | -110d | 0d |  | 168h | 結合ﾃｽﾄ結果、結合ﾃｽﾄ完了報告書 |
| 34 | 4.3.1 | SCL作成 |  | 5d | 2009-06-12 | 2009-06-18 |  | -110d | 0d | アナリスト | 40h |  |
| 35 | 4.3.2 | テスト実施 |  | 8d | 2009-06-19 | 2009-06-30 | 34 | -110d | 0d | テスト実施者 | 64h |  |
| 36 | 4.3.3 | PGM修正 |  | 8d | 2009-07-01 | 2009-07-10 | 35 | -110d | 0d | 開発者 | 64h |  |
| 37 | 4.4 | **総合テスト** |  | 23d | 2009-07-13 | 2009-08-12 | 33 | -110d | 0d |  | 184h | 総合テスト結果、総合テスト完了報告書 |
| 38 | 4.4.1 | SCL作成 |  | 3d | 2009-07-13 | 2009-07-15 |  | -110d | 0d | アナリスト | 24h |  |
| 39 | 4.4.2 | テスト実施 |  | 10d | 2009-07-16 | 2009-07-29 | 38 | -110d | 0d | テスト実施者 | 80h |  |
| 40 | 4.4.3 | PGM修正 |  | 10d | 2009-07-30 | 2009-08-12 | 39 | -110d | 0d | 開発者 | 80h |  |
| 41 | 4.5 | 運用（受入）確認 |  | 15d | 2009-08-13 | 2009-09-02 | 37 | -110d | 0d | ユーザー | 120h |  |
| 42 | 5 | **マニュアル作成** |  | 7d? | 2009-08-13 | 2009-08-21 | 37 | -70d | 0d |  | 56h |  |
| 43 | 5.1 | ユーザー向け操作マニュアル作成 |  | 6d | 2009-08-13 | 2009-08-20 |  | -70d | 0d | 中級ＳＥ | 48h | 操作マニュアル |
| 44 | 5.2 | 社内レビュー |  | 1d? | 2009-08-21 | 2009-08-21 | 43 | -70d | 0d | 管理者 | 8h |  |
| 45 | 6 | マニュアル 顧客レビュー |  | 3d | 2009-09-03 | 2009-09-07 | 42, 44 | -72d | 0d | ユーザー | 24h | マニュアルレビュー記録 |
| 46 | 7 | **移行・導入** |  | 48d | 2009-09-03 | 2009-11-09 |  | -110d | 0d |  | 408h | 移行・導入計画書 |
| 47 | 7.1 | テスト／本番環境の導入・運用展開の準備 |  | 20d | 2009-09-03 | 2009-09-30 | 41 | -110d | 0d | 基盤技術 | 160h |  |
| 48 | 7.2 | 移行評価項目の作成 |  | 10d | 2009-10-15 | 2009-10-28 | 47 | 61d |  | 基盤技術 | 80h |  |
| 49 | 7.3 | 運用評価項目の作成 |  | 10d | 2009-10-01 | 2009-10-14 | 47 | -110d | 0d | 基盤技術 | 80h |  |
| 50 | 7.4 | 社内レビュー |  | 1d | 2009-10-15 | 2009-10-15 | 49 | -110d | 0d | 管理者 | 8h |  |
| 51 | 7.5 | 移行・導入事前 顧客レビュー | milestone | 0d | 2009-10-15 | 2009-10-15 | 50 | -110d | 0d |  |  |  |
| 52 | 7.6 | **×××様テスト環境 導入テスト** |  | 5d | 2009-10-27 | 2009-11-02 | 67 | -117d | 0d |  | 40h |  |
| 53 | 7.6.1 | テストの実施 |  | 2d | 2009-10-27 | 2009-10-28 | 51 | -117d | 0d | テスト実施者 | 16h |  |
| 54 | 7.6.2 | テスト実施結果の課題整理 |  | 2d | 2009-10-29 | 2009-10-30 | 53 | -117d | 0d | 上級ＳＥ | 16h |  |
| 55 | 7.6.3 | テスト実施レビュー |  | 1d | 2009-11-02 | 2009-11-02 | 54 | -117d | 0d | 上級ＳＥ | 8h |  |

| ID | WBS | Task | Type | Duration | Start | Finish | Predecessors | Total slack | Free slack | Resources | Work | 主要なアウトプット |
| --- | --- | --- | --- | --- | --- | --- | --- | --- | --- | --- | --- | --- |
| 56 | 7.7 | **×××様本番環境 導入テスト** |  | 2d | 2009-11-03 | 2009-11-04 | 55 | -117d | 0d |  | 16h |  |
| 57 | 7.7.1 | テスト実施 |  | 1d | 2009-11-03 | 2009-11-03 |  | -117d | 0d | 上級ＳＥ | 8h |  |
| 58 | 7.7.2 | テスト実施レビュー |  | 1d | 2009-11-04 | 2009-11-04 | 57 | -117d | 0d | 上級ＳＥ | 8h |  |
| 59 | 7.8 | 出荷検査 |  | 1d | 2009-11-05 | 2009-11-05 | 58 | -117d | 0d | アナリスト | 8h |  |
| 60 | 7.9 | 導入判定会議 |  | 1d | 2009-11-06 | 2009-11-06 | 59 | -117d | 0d | ユーザー | 8h |  |
| 61 | 7.10 | 本番環境稼動リリース |  | 1d | 2009-11-09 | 2009-11-09 | 60, 67 | -117d | 0d | ユーザー | 8h |  |
| 62 | 8 | ユーザー検収作業 |  | 5d | 2009-11-10 | 2009-11-16 | 45, 61 | -117d | 0d | ユーザー | 40h |  |
| 63 | 9 | **追加開発（XX月XX日以降追加タスク）** |  | 70d | 2009-07-21 | 2009-10-26 |  | -119d | 0d |  | 264h |  |
| 64 | 9.1 | 設計 |  | 8d | 2009-07-21 | 2009-07-30 |  | -119d | 0d | 上級ＳＥ | 64h | ｼｽﾃﾑ機能仕様書 |
| 65 | 9.2 | 開発 |  | 15d | 2009-09-22 | 2009-10-12 | 64 | -117d | 0d | 開発者 | 120h | ソースコード |
| 66 | 9.3 | テスト |  | 10d | 2009-10-13 | 2009-10-26 | 65 | -117d | 0d | テスト実施者 | 80h | ﾃｽﾄ結果報告書 |
| 67 | 9.4 | テスト機導入 | milestone | 0d | 2009-10-26 | 2009-10-26 | 66 | -117d | 0d | 基盤技術 |  |  |
| 68 | 10 | プロジェクト完了評価 |  | 2d | 2009-11-17 | 2009-11-18 | 62 | -117d | 0d | ユーザー | 16h | ﾌﾟﾛｼﾞｪｸﾄ完了報告書 |
| 69 | 11 | プロジェクト完了 | milestone | 0d | 2009-11-18 | 2009-11-18 | 68 | 46d |  |  |  |  |
